# Programa Maestro DS185_OA_08 Reactor en S/E Ancud 220 kV

Schedule from MS Project, 2022-07-07 to 2025-12-15, status date 2025-09-20, A marks actual dates.

## Calendars

- Estándar: Mon-Sun 09:00-13:00, 15:00-19:00.

## Resources

| Resource |
| --- |
| 1 |

## Schedule

| ID | WBS | Task | Type | Duration | Start | Finish | Predecessors | Complete | Remaining | Baseline start | Baseline finish | Baseline duration | Baseline 1 start | Baseline 1 finish | Total slack | Free slack | Inicio Prog | Text3 | Text12 | % Complete Peso | % Baseline Peso | % Baseline (Tempo) | Entrada Peso | Text13 |
| --- | --- | --- | --- | --- | --- | --- | --- | --- | --- | --- | --- | --- | --- | --- | --- | --- | --- | --- | --- | --- | --- | --- | --- | --- |
| 1 | 1 | **HI - HITOS** |  | 1012d | 2023-03-10 A | 2025-12-15 |  |  | 1012d | 2023-03-10 | 2025-12-15 | 1012d | 2023-04-07 | 2025-09-01 | 0d |  | Día 246 | 1012 dc | -16% | 61,29% | 77,42% | 91% |  |  |
| 2 | 1.1 | **Hitos de Pago** |  | 1012d | 2023-03-10 A | 2025-12-15 |  |  | 1012d | 2023-03-10 | 2025-12-15 | 1012d | 2023-04-07 | 2025-09-01 | 0d |  | Día 246 | 1012 dc | -36% | 27,27% | 63,64% | 91% |  |  |
| 3 | 1.1.1 | (Hito de Pago N°1) Aprobación Programa Maestro y Lista de entregables de Ingeniería | milestone | 0d | 2023-03-10 A | 2023-03-10 A | 41 | 100% |  | 2023-03-10 | 2023-03-10 | 0d | 2023-04-07 | 2023-04-07 |  |  | Día 246 | 0 dc | -0% | 100,00% | 100,00% | 100% | 0,000000000001 |  |
| 4 | 1.1.2 | (Hito de Pago N°2) Revisión y Aprobación de Ingeniería Básica | milestone | 0d | 2023-11-21 A | 2023-11-21 A | 51 | 100% |  | 2023-11-21 | 2023-11-21 | 0d | 2023-08-20 | 2023-08-20 |  |  | Día 502 | 0 dc | -0% | 100,00% | 100,00% | 100% | 0,000000000001 |  |
| 5 | 1.1.3 | (Hito de Pago N°3) Revisión y Aprobación de Ingeniería de detalles | milestone | 0d | 2024-12-21 | 2024-12-21 | 56 |  |  | 2024-12-21 | 2024-12-21 | 0d | 2023-12-25 | 2023-12-25 | 359d |  | Día 898 | 0 dc | -100% | 0,00% | 100,00% | 100% | 0,000000000001 |  |
| 6 | 1.1.4 | (Hito de Pago N°4) Autorización Medio Ambiental para inicio construcción | milestone | 0d | 2024-01-11 A | 2024-01-11 A | 67, 79 | 100% |  | 2024-01-11 | 2024-01-11 | 0d | 2023-10-21 | 2023-10-21 |  |  | Día 553 | 0 dc | -0% | 100,00% | 100,00% | 100% | 0,000000000001 |  |
| 7 | 1.1.5 | (Hito de Pago N°5) Entrega en terreno del 100% equipamiento primario | milestone | 0d | 2024-09-11 | 2024-09-11 | 85FS+10d |  |  | 2024-09-11 | 2024-09-11 | 0d | 2024-06-09 | 2024-06-09 | 460d |  | Día 797 | 0 dc | -100% | 0,00% | 100,00% | 100% | 0,000000000001 |  |
| 8 | 1.1.6 | (Hito de Pago N°6) Entrega en terreno del 100% suministro principal ferretería AT | milestone | 0d | 2025-04-16 | 2025-04-16 | 92FS+10d |  |  | 2025-04-16 | 2025-04-16 | 0d | 2024-05-03 | 2024-05-03 | 243.4d |  | Día 1014 | 0 dc | -100% | 0,00% | 100,00% | 100% | 0,000000000001 |  |
| 9 | 1.1.7 | (Hito de Pago N°7) Aprobación del 100% Fundaciones, Estructuras y ampliación caseta de control | milestone | 0d | 2025-02-28 | 2025-02-28 | 119, 124, 125 |  |  | 2025-02-28 | 2025-02-28 | 0d | 2024-10-06 | 2024-10-06 | 290d |  | Día 967 | 0 dc | -100% | 0,00% | 100,00% | 100% | 0,000000000001 |  |
| 10 | 1.1.8 | (Hito de Pago N°8) Tendido de conductor de línea y/o Montaje Equipos principales AT | milestone | 0d | 2025-10-18 | 2025-10-18 | 136 |  |  | 2025-10-18 | 2025-10-18 | 0d | 2025-04-05 | 2025-04-05 | 58d |  | Día 1199 | 0 dc | -0% | 0,00% | 0,00% | 0% | 0,000000000001 |  |
| 11 | 1.1.9 | (Hito de Pago N°9) Aprobación del 100% Pruebas SAT Equipos de Control, Protecciones y Telecomunicaciones | milestone | 0d | 2025-10-28 | 2025-10-28 | 142 |  |  | 2025-10-28 | 2025-10-28 | 0d | 2025-04-13 | 2025-04-13 | 48d |  | Día 1209 | 0 dc | -0% | 0,00% | 0,00% | 0% | 0,000000000001 |  |
| 12 | 1.1.10 | (Hito de Pago N°10) Aprobación y recepción provisional del 100% de protocolos de puesta en servicio | milestone | 0d | 2025-11-30 | 2025-11-30 | 176 |  |  | 2025-11-30 | 2025-11-30 | 0d | 2025-08-01 | 2025-08-01 | 15d |  | Día 1242 | 0 dc | -0% | 0,00% | 0,00% | 0% | 0,000000000001 |  |
| 13 | 1.1.11 | (Hito de Pago N°11) Estado de Pago Final: Finalización del 100% de la lista de pendientes y firma acta devolución del terreno. | milestone | 0d | 2025-12-15 | 2025-12-15 | 177 |  |  | 2025-12-15 | 2025-12-15 | 0d | 2025-09-01 | 2025-09-01 | 0d |  | Día 1257 | 0 dc | -0% | 0,00% | 0,00% | 0% | 0,000000000001 |  |
| 14 | 1.2 | **Hitos Intermedios** |  | 839d | 2023-07-13 A | 2025-10-28 |  |  | 839d | 2023-07-13 | 2025-10-28 | 839d | 2023-05-28 | 2025-05-20 | 48d |  | Día 371 | 839 dc | -0% | 77,78% | 77,78% | 95% |  |  |
| 15 | 1.2.1 | (Hito Intermedio N°1 ) Entrega al Mandante de todos los estudios de terreno que se requieren para la correcta ejecución de la Obra en el Terreno, como, por ejemplo y sin que la lista sea taxativa, mecánica de suelos, Topografía u otro que aplicase. | milestone | 0d | 2023-07-13 A | 2023-07-13 A | 46 | 100% |  | 2023-07-13 | 2023-07-13 | 0d | 2023-05-28 | 2023-05-28 |  |  | Día 371 | 0 dc | -0% | 100,00% | 100,00% | 100% | 0,000000000001 |  |
| 16 | 1.2.2 | (Hito Intermedio N°2) Entrega al Mandante de la Ingeniería Básica en Rev. 0 aceptada por el Mandante y de los estudios que solicite el Coordinador para verificar el cumplimiento de las especificaciones técnicas de la obra. | milestone | 0d | 2023-11-21 A | 2023-11-21 A | 51 | 100% |  | 2023-11-21 | 2023-11-21 | 0d | 2023-11-14 | 2023-11-14 |  |  | Día 502 | 0 dc | -0% | 100,00% | 100,00% | 100% | 0,000000000001 |  |
| 17 | 1.2.3 | (Hito Intermedio N°3) Entrega al Mandante de los documentos que certifiquen la aprobación de los permisos necesarios para el inicio de la construcción de las obras. | milestone | 0d | 2024-01-11 A | 2024-01-11 A | 66, 79 | 100% |  | 2024-01-11 | 2024-01-11 | 0d | 2024-02-06 | 2024-02-06 |  |  | Día 553 | 0 dc | -0% | 100,00% | 100,00% | 100% | 0,000000000001 |  |
| 18 | 1.2.4 | (Hito Intermedio N°4) Entrega al Mandante de todos los documentos asociados a la Ingeniería de detalle del proyecto Electromecánico y de OOCC en Revisión 0 aceptado por el Mandante. | milestone | 0d | 2024-12-21 A | 2024-12-21 A | 56 | 100% |  | 2024-12-21 | 2024-12-21 | 0d | 2024-02-16 | 2024-02-16 |  |  | Día 898 | 0 dc | -0% | 100,00% | 100,00% | 100% | 0,000000000001 |  |
| 19 | 1.2.5 | (Hito Intermedio N°5) Entrega al Mandante de una copia del contrato firmado entre el Contratista y la ITO designada por el Coordinador para la Obra adjudicada. | milestone | 0d | 2023-12-05 A | 2023-12-05 A | 44 | 100% |  | 2023-12-05 | 2023-12-05 | 0d | 2023-11-29 | 2023-11-29 |  |  | Día 516 | 0 dc | -0% | 100,00% | 100,00% | 100% | 0,000000000001 |  |
| 20 | 1.2.6 | (Hito Intermedio N°6) Entrega al Mandante de una copia de las Órdenes de Compra de los equipos y/o estructuras en caso que aplicase. | milestone | 0d | 2023-08-04 A | 2023-08-04 A | 83 | 100% |  | 2023-08-04 | 2023-08-04 | 0d | 2023-08-14 | 2023-08-14 |  |  | Día 393 | 0 dc | -0% | 100,00% | 100,00% | 100% | 0,000000000001 | En revisión EDP |
| 21 | 1.2.7 | (Hito Intermedio N°7) Entrega al Mandante de documento emitido por la ITO que certifique que: recepción conforme del 100% de las fundaciones en el caso de ampliaciones de subestaciones; y tendido de conductor en caso de lineas. | milestone | 0d | 2025-10-18 | 2025-10-18 | 136 |  |  | 2025-10-18 | 2025-10-18 | 0d | 2024-10-25 | 2024-10-25 | 58d | 10d | Día 1199 | 0 dc | -0% | 0,00% | 0,00% | 0% | 0,000000000001 |  |
| 22 | 1.2.8 | (Hito Intermedio N°8) Entrega al Mandante de un documento que certifique que la ITO ha recibido conforme el montaje de los equipos primarios en SSEE y/o tendido de conductores en caso de líneas, según corresponda. | milestone | 0d | 2025-10-28 | 2025-10-28 | 21, 136, 144 |  |  | 2025-10-28 | 2025-10-28 | 0d | 2024-11-05 | 2024-11-05 | 48d |  | Día 1209 | 0 dc | -0% | 0,00% | 0,00% | 0% | 0,000000000001 |  |
| 23 | 1.2.9 | (Hito Intermedio N°9) Entrega al Mandante de todos los estudios e información solicitada por el Coordinador Eléctrico Nacional para la Puesta en Servicio de la Obra de acuerdo a lo establecido en las Bases Técnicas de la Obra. | milestone | 0d | 2025-05-20 A | 2025-05-20 A | 61, 139 | 100% |  | 2025-05-20 | 2025-05-20 | 0d | 2025-04-10 | 2025-04-10 |  |  | Día 1048 | 0 dc | -0% | 100,00% | 100,00% | 100% | 0,000000000001 |  |
| 24 | 1.3 | **Otros Hitos** |  | 960d | 2023-04-30 A | 2025-12-15 |  |  | 960d | 2023-04-30 | 2025-12-15 | 960d | 2023-04-30 | 2025-09-01 | 0d |  | Día 297 | 961 dc | -9% | 81,82% | 90,91% | 91% |  |  |
| 25 | 1.3.1 | **Contratación de Seguros** |  | 197d | 2023-04-30 A | 2023-11-14 A |  | 100% |  | 2023-04-30 | 2023-11-14 | 197d | 2023-04-30 | 2023-09-27 |  |  | Día 297 | 199 dc | -0% | 100,00% | 100,00% | 100% |  |  |
| 26 | 1.3.1.1 | Contratación Seguro Todo Riesgo de Construcción, Montaje y PES | milestone | 0d | 2023-11-14 A | 2023-11-14 A | 104SS-46d | 100% |  | 2023-11-14 | 2023-11-14 | 0d | 2023-09-27 | 2023-09-27 |  |  | Día 495 | 0 dc | -0% | 100,00% | 100,00% | 100% | 0,000000000001 |  |
| 27 | 1.3.1.2 | Contratación Seguro de Responsabilidad Civil + Adicionales | milestone | 0d | 2023-04-30 A | 2023-04-30 A | 26SS | 100% |  | 2023-04-30 | 2023-04-30 | 0d | 2023-04-30 | 2023-04-30 |  |  | Día 297 | 0 dc | -0% | 100,00% | 100,00% | 100% | 0,000000000001 |  |
| 28 | 1.3.1.3 | Contratación Seguro ALOP Todo Riesgo de Construcción, Montaje y PES | milestone | 0d | 2023-11-14 A | 2023-11-14 A | 26SS | 100% |  | 2023-11-14 | 2023-11-14 | 0d | 2023-09-27 | 2023-09-27 |  |  | Día 495 | 0 dc | -0% | 100,00% | 100,00% | 100% | 0,000000000001 |  |
| 29 | 1.3.1.4 | Contratación Seguro de Transporte Nacional e Internacional | milestone | 0d | 2023-11-14 A | 2023-11-14 A | 26SS | 100% |  | 2023-11-14 | 2023-11-14 | 0d | 2023-09-27 | 2023-09-27 |  |  | Día 495 | 0 dc | -0% | 100,00% | 100,00% | 100% | 0,000000000001 |  |
| 30 | 1.3.1.5 | Contratación Seguro ALOP Transporte de Suministros | milestone | 0d | 2023-11-14 A | 2023-11-14 A | 26SS | 100% |  | 2023-11-14 | 2023-11-14 | 0d | 2023-09-27 | 2023-09-27 |  |  | Día 495 | 0 dc | -0% | 100,00% | 100,00% | 100% | 0,000000000001 |  |
| 31 | 1.3.1.6 | Contratación Seguro Protección al Medio Ambiente | milestone | 0d | 2023-11-14 A | 2023-11-14 A | 26SS | 100% |  | 2023-11-14 | 2023-11-14 | 0d | 2023-09-27 | 2023-09-27 |  |  | Día 495 | 0 dc | -0% | 100,00% | 100,00% | 100% | 0,000000000001 |  |
| 32 | 1.3.1.7 | Contratación Seguro de Errores Profesionales y Omisiones | milestone | 0d | 2023-04-30 A | 2023-04-30 A | 26SS | 100% |  | 2023-04-30 | 2023-04-30 | 0d | 2023-04-30 | 2023-04-30 |  |  | Día 297 | 0 dc | -0% | 100,00% | 100,00% | 100% | 0,000000000001 |  |
| 33 | 1.3.2 | Recepción de Acta de entrega de Terreno | milestone | 0d | 2023-12-05 A | 2023-12-05 A | 39FS+242d | 100% |  | 2023-12-05 | 2023-12-05 | 0d | 2023-08-05 | 2023-08-05 |  |  | Día 516 | 0 dc | -0% | 100,00% | 100,00% | 100% | 0,000000000001 | Se realizará una vez aprobada la CP |
| 34 | 1.3.3 | Término Comisionamiento Equipos Primarios | milestone | 0d | 2025-05-20 | 2025-05-20 | 139 |  |  | 2025-05-20 | 2025-05-20 | 0d | 2025-05-20 | 2025-05-20 | 209d |  | Día 1048 | 0 dc | -100% | 0,00% | 100,00% | 100% | 0,000000000001 |  |
| 35 | 1.3.4 | Carta de Conexión al CEN | milestone | 0d | 2023-11-21 A | 2023-11-21 A | 51 | 100% |  | 2023-11-21 | 2023-11-21 | 0d | 2023-08-20 | 2023-08-20 |  |  | Día 502 | 0 dc | -0% | 100,00% | 100,00% | 100% | 0,000000000001 |  |
| 36 | 1.3.5 | Entrada en Operación de la Obra | milestone | 0d | 2025-12-15 | 2025-12-15 | 177 |  |  | 2025-12-15 | 2025-12-15 | 0d | 2025-09-01 | 2025-09-01 | 0d |  | Día 1257 | 0 dc | -0% | 0,00% | 0,00% | 0% | 0,000000000001 |  |

| ID | WBS | Task | Type | Duration | Start | Finish | Predecessors | Complete | Remaining | Baseline start | Baseline finish | Baseline duration | Baseline 1 start | Baseline 1 finish | Total slack | Constraint | Resources | Work | Actual work | Inicio Prog | Text3 | Text12 | % Complete Peso | % Baseline Peso | % Baseline (Tempo) | Entrada Peso | Text13 | Text14 |
| --- | --- | --- | --- | --- | --- | --- | --- | --- | --- | --- | --- | --- | --- | --- | --- | --- | --- | --- | --- | --- | --- | --- | --- | --- | --- | --- | --- | --- |
| 37 | 2 | **CO - CONTRATOS** |  | 279d | 2023-03-01 A | 2023-12-05 A |  | 100% |  | 2023-03-01 | 2023-12-05 | 279d | 2023-03-01 | 2024-05-30 |  |  |  | 608h | 608h | Día 237 | 280 dc | -0% | 100,00% | 100,00% | 100% | 0,26324 |  |  |
| 38 | 2.1 | Publicación Decreto de Adjudicación en Diario oficial | milestone | 1d | 2023-03-01 A | 2023-03-01 A |  | 100% |  | 2023-03-01 | 2023-03-01 | 1d | 2023-03-01 | 2023-03-01 |  | start no earlier than 2023-03-01 | 1 | 8h | 8h | Día 237 | 0 dc | -0% | 100,00% | 100,00% | 100% | 0,0069274654 |  |  |
| 39 | 2.2 | **Inicio de Contrato** |  | 32d | 2023-03-07 A | 2023-04-07 A |  | 100% |  | 2023-03-07 | 2023-04-07 | 32d | 2023-03-07 | 2023-04-07 |  |  |  | 16h | 16h | Día 243 | 32 dc | -0% | 100,00% | 100,00% | 100% |  |  |  |
| 40 | 2.2.1 | Firma del contrato con el propietario | milestone | 1d | 2023-03-07 A | 2023-03-07 A | 38FS+5d | 100% |  | 2023-03-07 | 2023-03-07 | 1d | 2023-03-07 | 2023-03-07 |  |  | 1 | 8h | 8h | Día 243 | 0 dc | -0% | 100,00% | 100,00% | 100% | 0,0069274654 |  |  |
| 41 | 2.2.2 | Entrega programa maestro del contrato y listado de entregables de ingenieria | milestone | 1d | 2023-04-07 A | 2023-04-07 A | 40FS+30d | 100% |  | 2023-04-07 | 2023-04-07 | 1d | 2023-04-07 | 2023-04-07 |  |  | 1 | 8h | 8h | Día 274 | 0 dc | -0% | 100,00% | 100,00% | 100% | 0,0069274654 |  |  |
| 42 | 2.3 | **Contrato Obra Adjudicada entre Contratista y la ITO** |  | 193d | 2023-05-26 A | 2023-12-05 A |  | 100% |  | 2023-05-26 | 2023-12-05 | 193d | 2023-09-22 | 2023-11-26 |  |  |  | 584h | 584h | Día 323 | 194 dc | -0% | 100,00% | 100,00% | 100% |  |  |  |
| 43 | 2.3.1 | Revisión y Aprobación del Mandante de ITO presentada en la oferta |  | 68d | 2023-05-26 A | 2023-08-01 A | 44FS-184d | 100% |  | 2023-05-26 | 2023-08-01 | 68d | 2023-09-22 | 2023-10-22 |  |  | 1 | 544h | 544h | Día 323 | 68 dc | -0% | 100,00% | 100,00% | 100% | 0,2078239609 |  |  |
| 44 | 2.3.2 | Contrato Obra Adjudicada entre Contratista y la ITO |  | 5d | 2023-11-30 A | 2023-12-05 A | 104SF-10d | 100% |  | 2023-11-30 | 2023-12-05 | 5d | 2023-11-21 | 2023-11-26 |  |  | 1 | 40h | 40h | Día 511 | 6 dc | -0% | 100,00% | 100,00% | 100% | 0,0346373268 |  |  |
| 45 | 3 | **IN - INGENIERÍA** |  | 1034d | 2022-07-07 A | 2025-05-05 |  | 99% | 7.54d | 2022-07-07 | 2025-05-05 | 1034d | 2023-04-29 | 2025-06-24 | 224d |  |  | 16456h | 16336h | Día 0 | 1034 dc | -2% | 98,23% | 100,00% | 100% | 7,00000 |  |  |
| 46 | 3.1 | **Estudios** |  | 30d | 2023-04-29 A | 2023-05-28 A |  | 100% |  | 2023-04-29 | 2023-05-28 | 30d | 2023-04-29 | 2023-05-28 |  |  |  | 960h | 960h | Día 296 | 30 dc | -0% | 100,00% | 100,00% | 100% |  |  |  |
| 47 | 3.1.1 | Estudios de mecánica de suelo |  | 30d | 2023-04-29 A | 2023-05-28 A | 39FS+21d | 100% |  | 2023-04-29 | 2023-05-28 | 30d | 2023-04-29 | 2023-05-28 |  |  | 1 | 240h | 240h | Día 296 | 30 dc | -0% | 100,00% | 100,00% | 100% | 0,2473498233 |  |  |
| 48 | 3.1.2 | Estudios de Resistividad de suelo para el Diseño de la Malla de tierra. |  | 30d | 2023-04-29 A | 2023-05-28 A | 47SS | 100% |  | 2023-04-29 | 2023-05-28 | 30d | 2023-04-29 | 2023-05-28 |  |  | 1 | 240h | 240h | Día 296 | 30 dc | -0% | 100,00% | 100,00% | 100% | 0,2473498233 |  |  |
| 49 | 3.1.3 | Medida de resistencia malla puesta a tierra existente |  | 30d | 2023-04-29 A | 2023-05-28 A | 47SS | 100% |  | 2023-04-29 | 2023-05-28 | 30d | 2023-04-29 | 2023-05-28 |  |  | 1 | 240h | 240h | Día 296 | 30 dc | -0% | 100,00% | 100,00% | 100% | 0,2473498233 |  |  |
| 50 | 3.1.4 | Topografía |  | 30d | 2023-04-29 A | 2023-05-28 A | 47SS | 100% |  | 2023-04-29 | 2023-05-28 | 30d | 2023-04-29 | 2023-05-28 |  |  | 1 | 240h | 240h | Día 296 | 30 dc | -0% | 100,00% | 100,00% | 100% | 0,2473498233 |  |  |
| 51 | 3.2 | **Ingeniería Básica** |  | 228d | 2023-04-08 A | 2023-11-21 A |  | 100% |  | 2023-04-08 | 2023-11-21 | 228d | 2023-05-29 | 2023-08-20 |  |  |  | 3576h | 3576h | Día 275 | 228 dc | -0% | 100,00% | 100,00% | 100% |  | Atraso por el EPC | Re-priorización de paquetes de ingeniería |
| 52 | 3.2.1 | Preparación de documentación para tramites ambientales y permisos |  | 92d | 2023-07-13 A | 2023-10-12 A | 46FS+7d | 100% |  | 2023-07-13 | 2023-10-12 | 92d | 2023-06-05 | 2023-08-03 |  |  | 1 | 736h | 736h | Día 371 | 92 dc | -0% | 100,00% | 100,00% | 100% | 0,4946996466 | Atraso por el EPC | Re-priorización de paquetes de ingeniería |
| 53 | 3.2.2 | Revisión de las caracteristicas garantizadas EEPP 66kV y MT |  | 97d | 2023-04-08 A | 2023-07-13 A | 41 | 100% |  | 2023-04-08 | 2023-07-13 | 97d | 2023-06-05 | 2023-07-19 |  |  | 1 | 776h | 776h | Día 275 | 97 dc | -0% | 100,00% | 100,00% | 100% | 0,3710247350 |  |  |
| 54 | 3.2.3 | Ingeniería Básica |  | 126d | 2023-07-13 A | 2023-11-15 A | 46 | 100% |  | 2023-07-13 | 2023-11-15 | 126d | 2023-05-29 | 2023-07-30 |  |  | 1 | 1008h | 1008h | Día 371 | 126 dc | -0% | 100,00% | 100,00% | 100% | 0,5194346290 | Atraso por el EPC | Re-priorización de paquetes de ingeniería |
| 55 | 3.2.4 | Revision por cliente |  | 132d | 2023-07-13 A | 2023-11-21 A | 54SS | 100% |  | 2023-07-13 | 2023-11-21 | 132d | 2023-07-31 | 2023-08-20 |  |  | 1 | 1056h | 1056h | Día 371 | 132 dc | -0% | 100,00% | 100,00% | 100% | 0,1731448763 |  |  |
| 56 | 3.3 | **Ingeniería Detalle** |  | 555d | 2023-06-16 A | 2024-12-21 A |  | 100% |  | 2023-06-16 | 2024-12-21 | 555d | 2023-08-21 | 2023-12-25 |  |  |  | 8400h | 8400h | Día 344 | 555 dc | -0% | 100,00% | 100,00% | 100% |  | Atraso por el EPC | Re-priorización de paquetes de ingeniería |
| 57 | 3.3.1 | Ingeniería Detalle OOCC |  | 350d | 2023-09-05 A | 2024-08-19 A | 54SS+54d | 100% |  | 2023-09-05 | 2024-08-19 | 350d | 2023-08-21 | 2023-11-18 |  |  | 1 | 2800h | 2800h | Día 425 | 350 dc | -0% | 100,00% | 100,00% | 100% | 0,7420494700 |  |  |
| 58 | 3.3.2 | Ingeniería Detalle Electromecanica |  | 350d | 2023-09-05 A | 2024-08-19 A | 57SS | 100% |  | 2023-09-05 | 2024-08-19 | 350d | 2023-08-28 | 2023-11-25 |  |  | 1 | 2800h | 2800h | Día 425 | 350 dc | -0% | 100,00% | 100,00% | 100% | 0,7420494700 |  |  |
| 59 | 3.3.3 | Ingeniería Detalle de Control y Protecciones |  | 350d | 2023-06-16 A | 2024-12-21 A | 58SS+30d | 100% |  | 2023-06-16 | 2024-12-21 | 350d | 2023-09-27 | 2023-12-25 |  |  | 1 | 2800h | 2800h | Día 344 | 555 dc | -0% | 100,00% | 100,00% | 100% | 0,7420494700 |  |  |
| 60 | 3.4 | **Estudios sistemicos** |  | 350d | 2023-12-07 A | 2024-11-20 A |  | 100% |  | 2023-12-07 | 2024-11-20 | 350d | 2023-09-05 | 2024-03-02 |  |  |  | 2800h | 2800h | Día 518 | 350 dc | -0% | 100,00% | 100,00% | 100% |  | Atraso por el EPC | Re-priorización de paquetes de ingeniería |
| 61 | 3.4.1 | Estudios electricos CEN |  | 350d | 2023-12-07 A | 2024-11-20 A | 35FS+15d | 100% |  | 2023-12-07 | 2024-11-20 | 350d | 2023-09-05 | 2024-03-02 |  |  | 1 | 2800h | 2800h | Día 518 | 350 dc | -0% | 100,00% | 100,00% | 100% | 1,4840989399 |  |  |

| ID | WBS | Task | Type | Duration | Start | Finish | Predecessors | Complete | Remaining | Baseline start | Baseline finish | Baseline duration | Baseline 1 start | Baseline 1 finish | Total slack | Resources | Work | Actual work | Inicio Prog | Text3 | Text12 | % Complete Peso | % Baseline Peso | % Baseline (Tempo) | Entrada Peso | Text13 | Text14 |
| --- | --- | --- | --- | --- | --- | --- | --- | --- | --- | --- | --- | --- | --- | --- | --- | --- | --- | --- | --- | --- | --- | --- | --- | --- | --- | --- | --- |
| 62 | 3.5 | **Otros de Ingeniería** |  | 1034d | 2022-07-07 A | 2025-05-05 |  | 83% | 172.33d | 2022-07-07 | 2025-05-05 | 1034d | 2023-12-26 | 2025-06-24 | 224d |  | 720h | 600h | Día 0 | 1034 dc | -17% | 83,33% | 100,00% | 100% |  |  |  |
| 63 | 3.5.1 | Planos As Built |  | 15d | 2022-07-07 | 2022-07-21 |  |  |  | 2022-07-07 | 2022-07-21 | 15d | 2025-06-10 | 2025-06-24 | 1243d | 1 | 120h |  | Día 0 | 15 dc | -100% | 0,00% | 100,00% | 100% | 0,1236749117 |  |  |
| 64 | 3.5.2 | Formularios Técnicos (FEM y FIT) |  | 15d | 2025-04-21 A | 2025-05-05 A | 123 | 100% |  | 2025-04-21 | 2025-05-05 | 15d | 2024-11-27 | 2024-12-11 |  | 1 | 120h | 120h | Día 1019 | 15 dc | -0% | 100,00% | 100,00% | 100% | 0,1236749117 |  |  |
| 65 | 3.5.3 | Ingeniería Detalle de Comunicaciones y SCADA |  | 60d | 2024-12-22 A | 2025-02-19 A | 59 | 100% |  | 2024-12-22 | 2025-02-19 | 60d | 2023-12-26 | 2024-02-23 |  | 1 | 480h | 480h | Día 899 | 60 dc | -0% | 100,00% | 100,00% | 100% | 0,4946996466 |  |  |
| 66 | 4 | **MA - MEDIO AMBIENTE** |  | 189d | 2023-04-08 A | 2023-10-13 A |  | 100% |  | 2023-04-08 | 2023-10-13 | 189d | 2023-05-23 | 2023-10-21 |  |  | 1512h | 1512h | Día 275 | 189 dc | -0% | 100,00% | 100,00% | 100% | 1,68044 |  |  |
| 67 | 4.1 | **Trámites ambientales** |  | 189d | 2023-04-08 A | 2023-10-13 A |  | 100% |  | 2023-04-08 | 2023-10-13 | 189d | 2023-05-23 | 2023-09-21 |  |  | 1512h | 1512h | Día 275 | 189 dc | -0% | 100,00% | 100,00% | 100% |  |  |  |
| 68 | 4.1.1 | Ingreso Evaluacion SEIA |  | 133d | 2023-04-08 A | 2023-08-18 A | 39 | 100% |  | 2023-04-08 | 2023-08-18 | 133d | 2023-05-23 | 2023-05-23 |  | 1 | 1064h | 1064h | Día 275 | 133 dc | -0% | 100,00% | 100,00% | 100% | 0,0137741047 | Atraso por el EPC | Se aceleran revisiones por ambas partes |
| 69 | 4.1.2 | Proceso de Calificacion |  | 55d | 2023-08-19 A | 2023-10-12 A | 68 | 100% |  | 2023-08-19 | 2023-10-12 | 55d | 2023-05-24 | 2023-09-20 |  | 1 | 440h | 440h | Día 408 | 55 dc | -0% | 100,00% | 100,00% | 100% | 1,6528925620 | Atraso por el EPC | Presentación a la autoridad del proyecto |
| 70 | 4.1.3 | Obtencion RCA |  | 1d | 2023-10-13 A | 2023-10-13 A | 69 | 100% |  | 2023-10-13 | 2023-10-13 | 1d | 2023-09-21 | 2023-09-21 |  | 1 | 8h | 8h | Día 463 | 0 dc | -0% | 100,00% | 100,00% | 100% | 0,0137741047 |  |  |
| 71 | 5 | **PE - PERMISOS** |  | 186d | 2023-07-10 A | 2024-01-11 |  | 94% | 10.57d | 2023-07-10 | 2024-01-11 | 186d | 2023-05-23 | 2023-10-21 | 704d |  | 3800h | 3584h | Día 368 | 186 dc | -4% | 96,27% | 100,00% | 100% | 3,31956 |  |  |
| 72 | 5.1 | Permisos de Construcción de las obras |  | 53d | 2023-10-14 A | 2023-12-05 A | 70 | 100% |  | 2023-10-14 | 2023-12-05 | 53d | 2023-05-23 | 2023-08-20 |  | 1 | 424h | 424h | Día 464 | 53 dc | -0% | 100,00% | 100,00% | 100% | 1,2396694215 | Atraso por el EPC | Se aceleran elaboraciones de carpetas |
| 73 | 5.2 | **Gestión Permisos Municipales / Servicios Publicos** |  | 186d | 2023-07-10 A | 2024-01-11 |  | 94% | 11.9d | 2023-07-10 | 2024-01-11 | 186d | 2023-09-22 | 2023-10-21 | 704d |  | 3376h | 3160h | Día 368 | 186 dc | -6% | 94,00% | 100,00% | 100% |  | Atraso por el EPC | Se aceleran elaboraciones de carpetas |
| 74 | 5.2.1 | **Elaboración y tramitación de permisos ante Direcciones Municipales y/o Servicios Públicos.** |  | 186d | 2023-07-10 A | 2024-01-11 |  | 94% | 11.9d | 2023-07-10 | 2024-01-11 | 186d | 2023-09-22 | 2023-10-21 | 704d |  | 3376h | 3160h | Día 368 | 186 dc | -6% | 94,00% | 100,00% | 100% |  |  |  |
| 75 | 5.2.1.1 | PAS 138 |  | 90d | 2023-10-14 A | 2024-01-11 | 67 | 70% | 27d | 2023-10-14 | 2024-01-11 | 90d | 2023-09-22 | 2023-10-21 | 704d | 1 | 720h | 504h | Día 464 | 90 dc | -30% | 70,00% | 100,00% | 100% | 0,4132231405 |  |  |
| 76 | 5.2.1.2 | PAS 140 |  | 90d | 2023-10-14 A | 2024-01-11 A | 67 | 100% |  | 2023-10-14 | 2024-01-11 | 90d | 2023-09-22 | 2023-10-21 |  | 1 | 720h | 720h | Día 464 | 90 dc | -0% | 100,00% | 100,00% | 100% | 0,4132231405 |  |  |
| 77 | 5.2.1.3 | PAS 142 |  | 90d | 2023-10-14 A | 2024-01-11 A | 67 | 100% |  | 2023-10-14 | 2024-01-11 | 90d | 2023-09-22 | 2023-10-21 |  | 1 | 720h | 720h | Día 464 | 90 dc | -0% | 100,00% | 100,00% | 100% | 0,4132231405 |  |  |
| 78 | 5.2.1.4 | PAS 148 |  | 90d | 2023-10-14 A | 2024-01-11 A | 67 | 100% |  | 2023-10-14 | 2024-01-11 | 90d | 2023-09-22 | 2023-10-21 |  | 1 | 720h | 720h | Día 464 | 90 dc | -0% | 100,00% | 100,00% | 100% | 0,4132231405 |  |  |
| 79 | 5.2.1.5 | IFC (PAS 160) |  | 62d | 2023-07-10 A | 2024-01-11 A | 67 | 100% |  | 2023-07-10 | 2024-01-11 | 62d | 2023-09-22 | 2023-10-21 |  | 1 | 496h | 496h | Día 368 | 186 dc | -0% | 100,00% | 100,00% | 100% | 0,4132231405 |  |  |
| 80 | 5.3 | (Hito Recepción de entrega de terreno) | milestone | 0d | 2023-12-05 A | 2023-12-05 A | 33 | 100% |  | 2023-12-05 | 2023-12-05 | 0d | 2023-08-06 | 2023-08-06 |  | 1 |  |  | Día 516 | 0 dc | -0% | 100,00% | 100,00% | 100% | 0,0137741047 | Se realizará en noviembre |  |
| 81 | 6 | **SU - SUMINISTROS** |  | 617.6d | 2023-07-29 A | 2025-04-06 A |  | 100% |  | 2023-07-29 | 2025-04-06 | 617.6d | 2023-08-04 | 2024-05-30 |  |  | 24624h | 24624h | Día 387 | 618 dc | -0% | 100,00% | 100,00% | 100% | 16,73676 |  |  |
| 82 | 6.1 | **Suministro de Equipos Primarios** |  | 617.6d | 2023-07-29 A | 2025-04-06 A |  | 100% |  | 2023-07-29 | 2025-04-06 | 617.6d | 2023-08-04 | 2024-05-30 |  |  | 24624h | 24624h | Día 387 | 618 dc | -0% | 100,00% | 100,00% | 100% |  |  |  |
| 83 | 6.1.1 | Emisión Orden de compra |  | 7d | 2023-07-29 A | 2023-08-04 A | 53FS+15d | 100% |  | 2023-07-29 | 2023-08-04 | 7d | 2023-08-04 | 2023-08-04 |  | 1 | 56h | 56h | Día 387 | 7 dc | -0% | 100,00% | 100,00% | 100% | 0,0069274654 |  |  |
| 84 | 6.1.2 | **Fabricación y Transporte** |  | 616.6d | 2023-07-30 A | 2025-04-06 A |  | 100% |  | 2023-07-30 | 2025-04-06 | 616.6d | 2023-08-05 | 2024-05-30 |  |  | 24568h | 24568h | Día 388 | 617 dc | -0% | 100,00% | 100,00% | 100% |  |  |  |
| 85 | 6.1.2.1 | **Equipos Primarios 220 kV** |  | 400d | 2023-07-30 A | 2024-09-01 A |  | 100% |  | 2023-07-30 | 2024-09-01 | 400d | 2023-08-05 | 2024-05-30 |  |  | 18448h | 18448h | Día 388 | 400 dc | -0% | 100,00% | 100,00% | 100% |  | Atraso por el EPC | Re-priorización de paquetes de ingeniería |
| 86 | 6.1.2.1.1 | Reactor 50 MVAr 220 kV |  | 306d | 2023-07-30 A | 2024-05-30 A | 83 | 100% |  | 2023-07-30 | 2024-05-30 | 306d | 2023-08-05 | 2024-05-30 |  | 1 | 2448h | 2448h | Día 388 | 306 dc | -0% | 100,00% | 100,00% | 100% | 2,0782396088 |  |  |
| 87 | 6.1.2.1.2 | Seccionador tripolar 220 kV |  | 400d | 2023-07-30 A | 2024-09-01 A | 86SS | 100% |  | 2023-07-30 | 2024-09-01 | 400d | 2023-08-05 | 2024-04-30 |  | 1 | 3200h | 3200h | Día 388 | 400 dc | -0% | 100,00% | 100,00% | 100% | 1,8704156479 |  |  |
| 88 | 6.1.2.1.3 | Interruptor de poder trifasico 220 kV |  | 400d | 2023-07-30 A | 2024-09-01 A | 86SS | 100% |  | 2023-07-30 | 2024-09-01 | 400d | 2023-08-05 | 2024-04-30 |  | 1 | 3200h | 3200h | Día 388 | 400 dc | -0% | 100,00% | 100,00% | 100% | 1,8704156479 |  |  |
| 89 | 6.1.2.1.4 | Transformador de potencial 220 kV |  | 400d | 2023-07-30 A | 2024-09-01 A | 86SS | 100% |  | 2023-07-30 | 2024-09-01 | 400d | 2023-08-05 | 2024-04-30 |  | 1 | 3200h | 3200h | Día 388 | 400 dc | -0% | 100,00% | 100,00% | 100% | 1,8704156479 |  |  |
| 90 | 6.1.2.1.5 | Pararrayos 220 kV |  | 400d | 2023-07-30 A | 2024-09-01 A | 86SS | 100% |  | 2023-07-30 | 2024-09-01 | 400d | 2023-08-05 | 2024-04-30 |  | 1 | 3200h | 3200h | Día 388 | 400 dc | -0% | 100,00% | 100,00% | 100% | 1,8704156479 |  |  |
| 91 | 6.1.2.1.6 | Aislador de pedestal 220 kV |  | 400d | 2023-07-30 A | 2024-09-01 A | 86SS | 100% |  | 2023-07-30 | 2024-09-01 | 400d | 2023-08-05 | 2024-04-30 |  | 1 | 3200h | 3200h | Día 388 | 400 dc | -0% | 100,00% | 100,00% | 100% | 1,8704156479 |  |  |

| ID | WBS | Task | Duration | Start | Finish | Predecessors | Complete | Remaining | Baseline start | Baseline finish | Baseline duration | Baseline 1 start | Baseline 1 finish | Total slack | Resources | Work | Actual work | Inicio Prog | Text3 | Text12 | % Complete Peso | % Baseline Peso | % Baseline (Tempo) | Entrada Peso |
| --- | --- | --- | --- | --- | --- | --- | --- | --- | --- | --- | --- | --- | --- | --- | --- | --- | --- | --- | --- | --- | --- | --- | --- | --- |
| 92 | 6.1.2.2 | **Suministros** | 428.6d | 2024-02-03 A | 2025-04-06 A |  | 100% |  | 2024-02-03 | 2025-04-06 | 428.6d | 2023-11-19 | 2024-04-23 |  |  | 6120h | 6120h | Día 576 | 429 dc | -0% | 100,00% | 100,00% | 100% |  |
| 93 | 6.1.2.2.1 | Sistema de Control y Protecciones | 120d | 2024-05-08 A | 2025-04-06 A | 59 | 100% |  | 2024-05-08 | 2025-04-06 | 120d | 2023-12-26 | 2024-04-23 |  | 1 | 960h | 960h | Día 671 | 334 dc | -0% | 100,00% | 100,00% | 100% | 0,8312958435 |
| 94 | 6.1.2.2.2 | Sistema de Comunicaciones | 120d | 2024-05-08 A | 2025-04-06 A | 59 | 100% |  | 2024-05-08 | 2025-04-06 | 120d | 2023-12-26 | 2024-04-23 |  | 1 | 960h | 960h | Día 671 | 334 dc | -0% | 100,00% | 100,00% | 100% | 0,8312958435 |
| 95 | 6.1.2.2.3 | Suministro para Servicios Auxiliares CC | 90d | 2024-02-13 A | 2024-11-07 A | 58 | 100% |  | 2024-02-13 | 2024-11-07 | 90d | 2023-11-26 | 2024-02-23 |  | 1 | 720h | 720h | Día 586 | 269 dc | -0% | 100,00% | 100,00% | 100% | 0,6234718826 |
| 96 | 6.1.2.2.4 | Suministros para Servicios auxiliares C.A. | 90d | 2024-02-13 A | 2024-05-12 A | 95SS | 100% |  | 2024-02-13 | 2024-05-12 | 90d | 2023-11-26 | 2024-02-23 |  | 1 | 720h | 720h | Día 586 | 90 dc | -0% | 100,00% | 100,00% | 100% | 0,6234718826 |
| 97 | 6.1.2.2.5 | Suministro Estructuras | 105d | 2024-02-03 A | 2024-11-19 A | 57 | 100% |  | 2024-02-03 | 2024-11-19 | 105d | 2023-11-19 | 2024-03-02 |  | 1 | 840h | 840h | Día 576 | 291 dc | -0% | 100,00% | 100,00% | 100% | 0,7273838631 |
| 98 | 6.1.2.2.6 | Suministro Aisladores | 60d | 2024-02-13 A | 2024-10-14 A | 58 | 100% |  | 2024-02-13 | 2024-10-14 | 60d | 2023-11-26 | 2024-01-24 |  | 1 | 480h | 480h | Día 586 | 245 dc | -0% | 100,00% | 100,00% | 100% | 0,4156479218 |
| 99 | 6.1.2.2.7 | Suministro Conductores y Ferreteria SSEE A.T. | 60d | 2024-02-13 A | 2024-10-14 A | 58 | 100% |  | 2024-02-13 | 2024-10-14 | 60d | 2023-11-26 | 2024-01-24 |  | 1 | 480h | 480h | Día 586 | 245 dc | -0% | 100,00% | 100,00% | 100% | 0,4156479218 |
| 100 | 6.1.2.2.8 | Suministro Conductores para B.T. | 60d | 2024-12-22 A | 2025-02-19 A | 59 | 100% |  | 2024-12-22 | 2025-02-19 | 60d | 2023-12-26 | 2024-02-23 |  | 1 | 480h | 480h | Día 899 | 60 dc | -0% | 100,00% | 100,00% | 100% | 0,4156479218 |
| 101 | 6.1.2.2.9 | Suministro Malla Puesta a tierra Base y Aerea | 60d | 2024-02-13 A | 2024-08-25 A | 58 | 100% |  | 2024-02-13 | 2024-08-25 | 60d | 2023-11-26 | 2024-01-24 |  | 1 | 480h | 480h | Día 586 | 195 dc | -0% | 100,00% | 100,00% | 100% | 0,4156479218 |
| 102 | 7 | **CT - CONSTRUCCIÓN** | 686.03d | 2023-12-15 A | 2025-10-31 |  | 95% | 35.19d | 2023-12-15 | 2025-10-31 | 686.03d | 2023-12-26 | 2025-09-01 | 45.97d |  | 4640h | 4402h | Día 526 | 687 dc | -0% | 98,21% | 98,52% | 94% | 41,39504 |
| 103 | 7.1 | **Movilización a Terreno** | 34d | 2023-12-15 A | 2024-01-17 A |  | 100% |  | 2023-12-15 | 2024-01-17 | 34d | 2023-12-26 | 2024-01-17 |  |  | 272h | 272h | Día 526 | 34 dc | -0% | 100,00% | 100,00% | 100% |  |
| 104 | 7.1.1 | Movilización | 16d | 2023-12-15 A | 2023-12-30 A | 33FS+9d, 72FS-41d, 67FS+10d, 70 | 100% |  | 2023-12-15 | 2023-12-30 | 16d | 2023-12-26 | 2023-12-26 |  | 1 | 128h | 128h | Día 526 | 16 dc | -0% | 100,00% | 100,00% | 100% | 0,1007092199 |
| 105 | 7.1.2 | **Instalación de Faena** | 18d | 2023-12-31 A | 2024-01-17 A |  | 100% |  | 2023-12-31 | 2024-01-17 | 18d | 2023-12-27 | 2024-01-17 |  |  | 144h | 144h | Día 542 | 18 dc | -0% | 100,00% | 100,00% | 100% |  |
| 106 | 7.1.2.1 | Instalación Container Oficinas | 11d | 2023-12-31 A | 2024-01-10 A | 104 | 100% |  | 2023-12-31 | 2024-01-10 | 11d | 2023-12-27 | 2024-01-10 |  | 1 | 88h | 88h | Día 542 | 11 dc | -0% | 100,00% | 100,00% | 100% | 1,0106382979 |
| 107 | 7.1.2.2 | Limpieza de área | 7d | 2024-01-11 A | 2024-01-17 A | 106 | 100% |  | 2024-01-11 | 2024-01-17 | 7d | 2024-01-11 | 2024-01-17 |  | 1 | 56h | 56h | Día 553 | 7 dc | -0% | 100,00% | 100,00% | 100% | 0,7049645390 |
| 108 | 7.2 | Topografia | 7d | 2024-01-18 A | 2024-01-24 A | 105 | 100% |  | 2024-01-18 | 2024-01-24 | 7d | 2024-01-18 | 2024-01-24 |  | 1 | 56h | 56h | Día 560 | 7 dc | -0% | 100,00% | 100,00% | 100% | 0,7049645390 |
| 109 | 7.3 | Accesos Provisorios | 7d | 2024-01-18 A | 2024-01-24 A | 105 | 100% |  | 2024-01-18 | 2024-01-24 | 7d | 2024-01-18 | 2024-01-24 |  | 1 | 56h | 56h | Día 560 | 7 dc | -0% | 100,00% | 100,00% | 100% | 0,7049645390 |
| 110 | 7.4 | **Adecuación plataforma subestacion** | 56d | 2024-01-25 A | 2024-03-20 A |  | 100% |  | 2024-01-25 | 2024-03-20 | 56d | 2024-01-25 | 2024-03-20 |  |  | 448h | 448h | Día 567 | 56 dc | -0% | 100,00% | 100,00% | 100% |  |
| 111 | 7.4.1 | Trabajos preliminares | 10d | 2024-01-25 A | 2024-02-03 A | 103, 108, 109 | 100% |  | 2024-01-25 | 2024-02-03 | 10d | 2024-01-25 | 2024-02-03 |  | 1 | 80h | 80h | Día 567 | 10 dc | -0% | 100,00% | 100,00% | 100% | 1,0070921986 |
| 112 | 7.4.2 | Escarpe | 10d | 2024-02-04 A | 2024-02-13 A | 111 | 100% |  | 2024-02-04 | 2024-02-13 | 10d | 2024-02-04 | 2024-02-13 |  | 1 | 80h | 80h | Día 577 | 10 dc | -0% | 100,00% | 100,00% | 100% | 1,0070921986 |
| 113 | 7.4.3 | Excavacion | 15d | 2024-02-14 A | 2024-02-28 A | 112 | 100% |  | 2024-02-14 | 2024-02-28 | 15d | 2024-02-14 | 2024-02-28 |  | 1 | 120h | 120h | Día 587 | 15 dc | -0% | 100,00% | 100,00% | 100% | 1,5106382979 |
| 114 | 7.4.4 | Relleno compactado | 21d | 2024-02-29 A | 2024-03-20 A | 113 | 100% |  | 2024-02-29 | 2024-03-20 | 21d | 2024-02-29 | 2024-03-20 |  | 1 | 168h | 168h | Día 602 | 21 dc | -0% | 100,00% | 100,00% | 100% | 2,1148936170 |
| 115 | 7.5 | **Construcción foso separador de aceite** | 70d | 2024-08-20 A | 2024-10-28 A |  | 100% |  | 2024-08-20 | 2024-10-28 | 70d | 2024-03-21 | 2024-05-29 |  |  | 560h | 560h | Día 775 | 70 dc | -0% | 100,00% | 100,00% | 100% |  |
| 116 | 7.5.1 | Excavación foso separador de aceite | 10d | 2024-08-20 A | 2024-08-29 A | 110, 57 | 100% |  | 2024-08-20 | 2024-08-29 | 10d | 2024-03-21 | 2024-03-30 |  | 1 | 80h | 80h | Día 775 | 10 dc | -0% | 100,00% | 100,00% | 100% | 1,0070921986 |
| 117 | 7.5.2 | Construcción de foso de aceite | 45d | 2024-08-30 A | 2024-10-13 A | 116 | 100% |  | 2024-08-30 | 2024-10-13 | 45d | 2024-03-31 | 2024-05-14 |  | 1 | 360h | 360h | Día 785 | 45 dc | -0% | 100,00% | 100,00% | 100% | 4,5319148936 |
| 118 | 7.5.3 | Terminaciones foso de aceite | 15d | 2024-10-14 A | 2024-10-28 A | 117 | 100% |  | 2024-10-14 | 2024-10-28 | 15d | 2024-05-15 | 2024-05-29 |  | 1 | 120h | 120h | Día 830 | 15 dc | -0% | 100,00% | 100,00% | 100% | 1,5106382979 |

| ID | WBS | Task | Duration | Start | Finish | Predecessors | Complete | Remaining | Baseline start | Baseline finish | Baseline duration | Baseline 1 start | Baseline 1 finish | Total slack | Free slack | Resources | Work | Actual work | Inicio Prog | Text3 | Text12 | % Complete Peso | % Baseline Peso | % Baseline (Tempo) | Entrada Peso |
| --- | --- | --- | --- | --- | --- | --- | --- | --- | --- | --- | --- | --- | --- | --- | --- | --- | --- | --- | --- | --- | --- | --- | --- | --- | --- |
| 119 | 7.6 | **Construcción fundacion transformador de poder 50 MVA 220/23 kV** | 49d | 2024-10-29 A | 2024-12-16 A |  | 100% |  | 2024-10-29 | 2024-12-16 | 49d | 2024-05-30 | 2024-07-17 |  |  |  | 392h | 392h | Día 845 | 49 dc | -0% | 100,00% | 100,00% | 100% |  |
| 120 | 7.6.1 | Movimiento de tierra | 7d | 2024-10-29 A | 2024-11-04 A | 57, 110, 115 | 100% |  | 2024-10-29 | 2024-11-04 | 7d | 2024-05-30 | 2024-06-05 |  |  | 1 | 56h | 56h | Día 845 | 7 dc | -0% | 100,00% | 100,00% | 100% | 0,7049645390 |
| 121 | 7.6.2 | Construccion macizo central | 21d | 2024-11-05 A | 2024-11-25 A | 120, 86FF | 100% |  | 2024-11-05 | 2024-11-25 | 21d | 2024-06-06 | 2024-06-26 |  |  | 1 | 168h | 168h | Día 852 | 21 dc | -0% | 100,00% | 100,00% | 100% | 2,1148936170 |
| 122 | 7.6.3 | Construccion canaleta colectora de aceite | 21d | 2024-11-26 A | 2024-12-16 A | 121 | 100% |  | 2024-11-26 | 2024-12-16 | 21d | 2024-06-27 | 2024-07-17 |  |  | 1 | 168h | 168h | Día 873 | 21 dc | -0% | 100,00% | 100,00% | 100% | 2,1148936170 |
| 123 | 7.7 | **Construcción y montaje Paño J3** | 341d | 2024-05-15 A | 2025-04-20 A |  | 100% |  | 2024-05-15 | 2025-04-20 | 341d | 2024-07-18 | 2024-11-26 |  |  |  | 1216h | 1216h | Día 678 | 341 dc | -0% | 100,00% | 100,00% | 100% |  |
| 124 | 7.7.1 | Construccion fundaciones equipos y estructuras altas | 80d | 2024-05-15 A | 2025-02-07 A | 119, 57 | 100% |  | 2024-05-15 | 2025-02-07 | 80d | 2024-07-18 | 2024-09-15 |  |  | 1 | 640h | 640h | Día 678 | 269 dc | -0% | 100,00% | 100,00% | 100% | 6,0425531915 |
| 125 | 7.7.2 | Montaje de estructuras soporte equipos y estructuras altas | 21d | 2025-02-08 A | 2025-02-28 A | 124, 97 | 100% |  | 2025-02-08 | 2025-02-28 | 21d | 2024-09-16 | 2024-10-06 |  |  | 1 | 168h | 168h | Día 947 | 21 dc | -0% | 100,00% | 100,00% | 100% | 2,1148936170 |
| 126 | 7.7.3 | Montaje equipos 220 kV | 21d | 2025-03-01 A | 2025-03-21 A | 125, 85, 7 | 100% |  | 2025-03-01 | 2025-03-21 | 21d | 2024-10-07 | 2024-10-27 |  |  | 1 | 168h | 168h | Día 968 | 21 dc | -0% | 100,00% | 100,00% | 100% | 2,1148936170 |
| 127 | 7.7.4 | Montaje reactor 220 kV | 30d | 2025-03-22 A | 2025-04-20 A | 126, 85, 7 | 100% |  | 2025-03-22 | 2025-04-20 | 30d | 2024-10-28 | 2024-11-26 |  |  | 1 | 240h | 240h | Día 989 | 30 dc | -0% | 100,00% | 100,00% | 100% | 3,0212765957 |
| 128 | 7.8 | **Canalizaciones y tendido de conductores patio 220 kV** | 193.03d | 2025-04-21 A | 2025-10-31 |  | 85% | 28.01d | 2025-04-21 | 2025-10-31 | 193.03d | 2024-11-27 | 2025-02-06 | 45.97d |  |  | 1640h | 1402h | Día 1019 | 194 dc | -2% | 89,79% | 91,54% | 79% |  |
| 129 | 7.8.1 | Construccion de canalizaciones patio 220 kV y patio reactor | 30d | 2025-04-21 A | 2025-05-20 A | 58, 119, 123 | 100% |  | 2025-04-21 | 2025-05-20 | 30d | 2024-11-27 | 2024-12-26 |  |  | 1 | 240h | 240h | Día 1019 | 30 dc | -0% | 100,00% | 100,00% | 100% | 3,0212765957 |
| 130 | 7.8.2 | Montaje canalizaciones a equipos | 90d | 2025-05-21 A | 2025-08-18 A | 129 | 100% |  | 2025-05-21 | 2025-08-18 | 90d | 2024-12-27 | 2025-01-16 |  |  | 1 | 720h | 720h | Día 1049 | 90 dc | -0% | 100,00% | 100,00% | 100% | 2,1148936170 |
| 131 | 7.8.3 | Tendido de conductores y conexionado | 85d | 2025-06-11 A | 2025-10-31 | 130, 59, 100 | 65% | 29.75d | 2025-06-11 | 2025-10-31 | 85d | 2025-01-17 | 2025-02-06 | 45.97d |  | 1 | 680h | 442h | Día 1070 | 143 dc | -6% | 65,00% | 71,00% | 71% | 2,1148936170 |
| 132 | 8 | **MO - MONTAJES** | 482.5d | 2024-08-12 A | 2025-12-07 |  | 69% | 149.15d | 2024-08-12 | 2025-12-07 | 482.5d | 2025-02-07 | 2025-07-02 | 8.5d |  |  | 3728h | 2575.6h | Día 767 | 483 dc | -0% | 48,21% | 48,64% | 83% | 23,56596 |
| 133 | 8.1 | **MPAT patio 220 kV** | 165d | 2024-08-12 A | 2025-01-23 A |  | 100% |  | 2024-08-12 | 2025-01-23 | 165d | 2025-02-07 | 2025-03-14 |  |  |  | 1320h | 1320h | Día 767 | 165 dc | -0% | 100,00% | 100,00% | 100% |  |
| 134 | 8.1.1 | Construccion malla base ampliación | 150d | 2024-08-12 A | 2025-01-08 A | 124SS | 100% |  | 2024-08-12 | 2025-01-08 | 150d | 2025-02-07 | 2025-02-27 |  |  | 1 | 1200h | 1200h | Día 767 | 150 dc | -0% | 100,00% | 100,00% | 100% | 2,1148936170 |
| 135 | 8.1.2 | Chicoteo a equipos y estructuras | 15d | 2025-01-09 A | 2025-01-23 A | 134 | 100% |  | 2025-01-09 | 2025-01-23 | 15d | 2025-02-28 | 2025-03-14 |  |  | 1 | 120h | 120h | Día 917 | 15 dc | -0% | 100,00% | 100,00% | 100% | 1,5106382979 |
| 136 | 8.2 | **Tendido de conductores y chicoteo de equipos** | 106d | 2025-07-05 A | 2025-10-18 |  | 80% | 21.46d | 2025-07-05 | 2025-10-18 | 106d | 2025-03-15 | 2025-04-05 | 0d |  |  | 960h | 765.6h | Día 1094 | 106 dc | 17% | 70,68% | 53,95% | 73% |  |
| 137 | 8.2.1 | Tendido de conductores barra 220 kV | 90d | 2025-07-05 A | 2025-10-02 | 127FS+75d | 85% | 13.5d | 2025-07-05 | 2025-10-02 | 90d | 2025-03-15 | 2025-03-21 | 5.2d | 0d | 1 | 720h | 612h | Día 1094 | 90 dc | -1% | 85,00% | 86,00% | 86% | 0,7049645390 |
| 138 | 8.2.2 | Chicoteo de equipos patio 220 kV | 30d | 2025-09-03 A | 2025-10-18 | 137 | 64% | 10.8d | 2025-09-03 | 2025-10-18 | 30d | 2025-03-22 | 2025-04-05 | 0d |  | 1 | 240h | 153.6h | Día 1154 | 46 dc | 25% | 64,00% | 39,00% | 39% | 1,5106382979 |
| 139 | 8.3 | **Pruebas a equipos** | 95d | 2025-02-15 A | 2025-05-20 A |  | 100% |  | 2025-02-15 | 2025-05-20 | 95d | 2025-04-06 | 2025-05-20 |  |  |  | 360h | 360h | Día 954 | 95 dc | -0% | 100,00% | 100,00% | 100% |  |
| 140 | 8.3.1 | Pruebas a equipos patio 220 kV | 15d | 2025-02-15 A | 2025-03-01 A | 136, 5FS-90d | 100% |  | 2025-02-15 | 2025-03-01 | 15d | 2025-04-06 | 2025-04-20 |  |  | 1 | 120h | 120h | Día 954 | 15 dc | -0% | 100,00% | 100,00% | 100% | 1,5106382979 |
| 141 | 8.3.2 | Pruebas a reactor | 30d | 2025-04-21 A | 2025-05-20 A | 140, 127 | 100% |  | 2025-04-21 | 2025-05-20 | 30d | 2025-04-21 | 2025-05-20 |  |  | 1 | 240h | 240h | Día 1019 | 30 dc | -0% | 100,00% | 100,00% | 100% | 3,0212765957 |
| 142 | 8.4 | **Montaje armario de control y protecciones caseta de control** | 40d | 2025-09-19 | 2025-10-28 |  |  |  | 2025-09-19 | 2025-10-28 | 40d | 2025-03-15 | 2025-04-13 | 0d |  |  | 320h |  | Día 1170 | 40 dc | -6% | 0,00% | 6,50% | 4% |  |
| 143 | 8.4.1 | Montaje equipos en sala de celdas | 15d | 2025-09-19 | 2025-10-03 | 130FS+31d |  |  | 2025-09-19 | 2025-10-03 | 15d | 2025-03-15 | 2025-03-29 | 0d |  | 1 | 120h |  | Día 1170 | 15 dc | -13% | 0,00% | 13,00% | 13% | 1,5106382979 |
| 144 | 8.4.2 | Pruebas a equipos de control | 25d | 2025-10-04 | 2025-10-28 | 143 |  |  | 2025-10-04 | 2025-10-28 | 25d | 2025-03-30 | 2025-04-13 | 0d |  | 1 | 200h |  | Día 1185 | 25 dc | -0% | 0,00% | 0,00% | 0% | 1,5106382979 |

| ID | WBS | Task | Type | Duration | Start | Finish | Predecessors | Complete | Remaining | Baseline start | Baseline finish | Baseline duration | Baseline 1 start | Baseline 1 finish | Total slack | Free slack | Resources | Work | Actual work | Inicio Prog | Text3 | Text12 | % Complete Peso | % Baseline Peso | % Baseline (Tempo) | Entrada Peso |
| --- | --- | --- | --- | --- | --- | --- | --- | --- | --- | --- | --- | --- | --- | --- | --- | --- | --- | --- | --- | --- | --- | --- | --- | --- | --- | --- |
| 145 | 8.5 | **Conexión Paño JT3** |  | 22d | 2025-10-19 | 2025-11-09 | 139 |  |  | 2025-10-19 | 2025-11-09 | 22d | 2025-05-21 | 2025-06-11 | 0d |  |  | 176h |  | Día 1200 | 22 dc | -0% | 0,00% | 0,00% | 0% |  |
| 146 | 8.5.1 | Solicitud de desconexion barra 220 kV |  | 21d | 2025-10-19 | 2025-11-08 | 136, 61 |  |  | 2025-10-19 | 2025-11-08 | 21d | 2025-05-21 | 2025-06-10 | 0d |  | 1 | 168h |  | Día 1200 | 21 dc | -0% | 0,00% | 0,00% | 0% | 2,1148936170 |
| 147 | 8.5.2 | Conexión paño JT3 |  | 1d | 2025-11-09 | 2025-11-09 | 146 |  |  | 2025-11-09 | 2025-11-09 | 1d | 2025-06-11 | 2025-06-11 | 21d |  | 1 | 8h |  | Día 1221 | 0 dc | -0% | 0,00% | 0,00% | 0% | 0,1007092199 |
| 148 | 8.6 | **Conexión reactor 50 MVAr 220 kV** |  | 22d | 2025-11-09 | 2025-11-30 |  |  |  | 2025-11-09 | 2025-11-30 | 22d | 2025-06-11 | 2025-07-02 | 0d |  |  | 176h |  | Día 1221 | 22 dc | -0% | 0,00% | 0,00% | 0% |  |
| 149 | 8.6.1 | Solicitud de desconexion paño J3 |  | 21d | 2025-11-09 | 2025-11-29 | 146 |  |  | 2025-11-09 | 2025-11-29 | 21d | 2025-06-11 | 2025-07-01 | 0d |  | 1 | 168h |  | Día 1221 | 21 dc | -0% | 0,00% | 0,00% | 0% | 2,1148936170 |
| 150 | 8.6.2 | Conexión Reactor 50 MVAr |  | 1d | 2025-11-30 | 2025-11-30 | 149 |  |  | 2025-11-30 | 2025-11-30 | 1d | 2025-07-02 | 2025-07-02 | 0d |  | 1 | 8h |  | Día 1242 | 0 dc | -0% | 0,00% | 0,00% | 0% | 0,1007092199 |
| 151 | 8.7 | **Obras Civiles de adecuación** |  | 270.9d | 2025-03-11 A | 2025-12-07 |  | 31% | 186.24d | 2025-03-11 | 2025-12-07 | 270.9d | 2025-04-14 | 2025-06-09 | 8.5d |  |  | 416h | 130h | Día 978 | 272 dc | -5% | 28,51% | 33,33% | 71% |  |
| 152 | 8.7.1 | Construccion de caminos |  | 15d | 2025-03-11 A | 2025-11-05 | 142 | 75% | 3.75d | 2025-03-11 | 2025-11-05 | 15d | 2025-04-14 | 2025-04-28 | 0d |  | 1 | 120h | 90h | Día 978 | 240 dc | -5% | 75,00% | 80,00% | 80% | 1,5106382979 |
| 153 | 8.7.2 | Gravilla en patio |  | 10d | 2025-11-05 | 2025-11-15 | 152 |  |  | 2025-11-05 | 2025-11-15 | 10d | 2025-04-29 | 2025-05-08 | 0d |  | 1 | 80h |  | Día 1217 | 11 dc | -0% | 0,00% | 0,00% | 0% | 1,0070921986 |
| 154 | 8.7.3 | Limpieza y Retiro de escombros |  | 7d | 2025-11-15 | 2025-11-22 | 153 |  |  | 2025-11-15 | 2025-11-22 | 7d | 2025-05-09 | 2025-05-15 | 0d |  | 1 | 56h |  | Día 1227 | 8 dc | -0% | 0,00% | 0,00% | 0% | 0,7049645390 |
| 155 | 8.7.4 | Cercos |  | 10d | 2025-04-12 A | 2025-11-27 | 154 | 50% | 5d | 2025-04-12 | 2025-11-27 | 10d | 2025-05-16 | 2025-05-25 | 8.5d | 0d | 1 | 80h | 40h | Día 1010 | 230 dc | -20% | 50,00% | 70,00% | 70% | 1,0070921986 |
| 156 | 8.7.5 | Levantamiento de pendientes |  | 10d | 2025-11-27 | 2025-12-07 | 155 |  |  | 2025-11-27 | 2025-12-07 | 10d | 2025-05-26 | 2025-06-09 | 8.5d |  | 1 | 80h |  | Día 1239 | 11 dc | -0% | 0,00% | 0,00% | 0% | 1,5106382979 |
| 157 | 9 | **PI - PROCESO INTERCONEXIÓN** |  | 455d | 2024-09-02 A | 2025-11-30 |  | 88% | 56.05d | 2024-09-02 | 2025-11-30 | 455d | 2024-09-02 | 2025-09-01 | 0d |  |  |  |  | Día 788 | 455 dc | 2% | 56,82% | 54,55% | 84% | 0,50000 |
| 158 | 9.1 | Envio Carta (SIPC) |  | 30d | 2024-09-02 A | 2024-10-01 A |  | 100% |  | 2024-09-02 | 2024-10-01 | 30d | 2024-09-02 | 2024-10-01 |  |  |  |  |  | Día 788 | 30 dc | -0% | 100,00% | 100,00% | 100% | 0,04545455 |
| 159 | 9.2 | Recepción Carta Escenarios Minimos |  | 30d | 2024-10-02 A | 2024-10-31 A | 158 | 100% |  | 2024-10-02 | 2024-10-31 | 30d | 2024-10-02 | 2024-10-31 |  |  |  |  |  | Día 818 | 30 dc | -0% | 100,00% | 100,00% | 100% | 0,04545455 |
| 160 | 9.3 | Elaboración de FIT |  | 90d | 2024-10-02 A | 2024-12-30 A | 158 | 100% |  | 2024-10-02 | 2024-12-30 | 90d | 2024-10-02 | 2024-12-30 |  |  |  |  |  | Día 818 | 90 dc | -0% | 100,00% | 100,00% | 100% | 0,04545455 |
| 161 | 9.4 | Tramitación FIT |  | 120d | 2024-12-31 A | 2025-04-29 A | 160 | 100% |  | 2024-12-31 | 2025-04-29 | 120d | 2024-12-31 | 2025-04-29 |  |  |  |  |  | Día 908 | 120 dc | -0% | 100,00% | 100,00% | 100% | 0,04545455 |
| 162 | 9.5 | Elaboración ECAP y Estudios sistémicos |  | 180d | 2024-11-01 A | 2025-04-29 A | 160SS+30d, 161FF | 100% |  | 2024-11-01 | 2025-04-29 | 180d | 2024-11-01 | 2025-04-29 |  |  |  |  |  | Día 848 | 180 dc | -0% | 100,00% | 100,00% | 100% | 0,04545455 |
| 163 | 9.6 | Tramitación ECAP |  | 90d | 2025-04-30 A | 2025-07-28 A | 161, 162 | 100% |  | 2025-04-30 | 2025-07-28 | 90d | 2025-04-30 | 2025-07-28 |  |  |  |  |  | Día 1028 | 90 dc | -0% | 100,00% | 100,00% | 100% | 0,04545455 |
| 164 | 9.7 | Protocolos de equipos y Protecciones |  | 15d | 2025-10-29 | 2025-11-12 | 144 |  |  | 2025-10-29 | 2025-11-12 | 15d | 2025-04-30 | 2025-05-19 | 0d |  |  |  |  | Día 1210 | 15 dc | -0% | 0,00% | 0,00% | 0% | 0,04545455 |
| 165 | 9.8 | Revisión Protocolos y Print Out |  | 18d | 2025-11-13 | 2025-11-30 | 164 |  |  | 2025-11-13 | 2025-11-30 | 18d | 2025-07-04 | 2025-09-01 | 0d |  |  |  |  | Día 1225 | 18 dc | -0% | 0,00% | 0,00% | 0% | 0,04545455 |
| 166 | 9.9 | Sistema de medidas (SITR, FED, FIT PES, EME, GM) |  | 18d | 2025-11-13 A | 2025-11-30 | 165FF | 25% | 13.5d | 2025-11-13 | 2025-11-30 | 18d | 2025-06-12 | 2025-07-03 | 0d |  |  |  |  | Día 1225 | 18 dc | 25% | 25,00% | 0,00% | 0% | 0,04545455 |
| 167 | 9.10 | Revisión FED, E.M,E FIT PES , Pruebas SITR,GM |  | 30d | 2025-11-01 | 2025-11-30 | 166FF |  |  | 2025-11-01 | 2025-11-30 | 30d | 2025-07-04 | 2025-09-01 | 0d |  |  |  |  | Día 1213 | 30 dc | -0% | 0,00% | 0,00% | 0% | 0,04545455 |
| 168 | 9.11 | Puesta en Servicio | milestone | 0d | 2025-11-30 | 2025-11-30 | 176, 167 |  |  | 2025-11-30 | 2025-11-30 | 0d | 2025-09-01 | 2025-09-01 | 0d |  |  |  |  | Día 1242 | 0 dc | -0% | 0,00% | 0,00% | 0% | 0,04545455 |

| ID | WBS | Task | Type | Duration | Start | Finish | Predecessors | Baseline start | Baseline finish | Baseline duration | Baseline 1 start | Baseline 1 finish | Total slack | Resources | Work | Inicio Prog | Text3 | Text12 | % Complete Peso | % Baseline Peso | % Baseline (Tempo) | Entrada Peso |
| --- | --- | --- | --- | --- | --- | --- | --- | --- | --- | --- | --- | --- | --- | --- | --- | --- | --- | --- | --- | --- | --- | --- |
| 169 | 10 | **PS - PUESTA EN SERVICIO** |  | 29d | 2025-11-17 | 2025-12-15 |  | 2025-11-17 | 2025-12-15 | 29d | 2025-07-08 | 2025-09-01 | 0d |  | 120h | Día 1229 | 29 dc | -0% | 0,00% | 0,00% | 0% | 5,53901 |
| 170 | 10.1 | **Puesto en servicio Paño J3 y Reactor** |  | 14d | 2025-11-17 | 2025-11-30 |  | 2025-11-17 | 2025-11-30 | 14d | 2025-07-08 | 2025-07-16 | 0d |  | 120h | Día 1229 | 14 dc | -0% | 0,00% | 0,00% | 0% |  |
| 171 | 10.1.1 | Integración y pruebas señales al Scada |  | 5d | 2025-11-17 | 2025-11-21 | 146FS+8d | 2025-11-17 | 2025-11-21 | 5d | 2025-07-08 | 2025-07-09 | 0d | 1 | 40h | Día 1229 | 5 dc | -0% | 0,00% | 0,00% | 0% | 0,2014184397 |
| 172 | 10.1.2 | Pruebas punto a punto con CDEC-SEN |  | 3d | 2025-11-22 | 2025-11-24 | 171 | 2025-11-22 | 2025-11-24 | 3d | 2025-07-10 | 2025-07-11 | 0d | 1 | 24h | Día 1234 | 3 dc | -0% | 0,00% | 0,00% | 0% | 0,2014184397 |
| 173 | 10.1.3 | Pruebas telecomunicaciones y teleprotecciones |  | 3d | 2025-11-25 | 2025-11-27 | 172 | 2025-11-25 | 2025-11-27 | 3d | 2025-07-12 | 2025-07-13 | 0d | 1 | 24h | Día 1237 | 3 dc | -0% | 0,00% | 0,00% | 0% | 0,2014184397 |
| 174 | 10.1.4 | Energizacion paños J3 y reactor |  | 3d | 2025-11-28 | 2025-11-30 | 148FF, 173FF+3d | 2025-11-28 | 2025-11-30 | 3d | 2025-07-14 | 2025-07-15 | 0d | 1 | 24h | Día 1240 | 3 dc | -0% | 0,00% | 0,00% | 0% | 0,2014184397 |
| 175 | 10.1.5 | Puesta en servicios paños J3 y reactor |  | 1d | 2025-11-30 | 2025-11-30 | 150FF | 2025-11-30 | 2025-11-30 | 1d | 2025-07-16 | 2025-07-16 | 0d | 1 | 8h | Día 1242 | 0 dc | -0% | 0,00% | 0,00% | 0% | 0,1007092199 |
| 176 | 10.2 | Hito puesta en servicio general | milestone | 0d | 2025-11-30 | 2025-11-30 | 147, 150 | 2025-11-30 | 2025-11-30 | 0d | 2025-07-17 | 2025-08-01 | 0d | 1 |  | Día 1242 | 0 dc | -0% | 0,00% | 0,00% | 0% | 1,6113475177 |
| 177 | 10.3 | Hito Entrada en Operación | milestone | 0d | 2025-12-15 | 2025-12-15 | 176FS+15d, 168FS+15d, 175FS+15d, 174FS+15d | 2025-12-15 | 2025-12-15 | 0d | 2025-08-03 | 2025-09-01 | 0d | 1 |  | Día 1257 | 0 dc | -0% | 0,00% | 0,00% | 0% | 3,0212765957 |
